# Learnerships Plan.Generic

Schedule from MS Project, 2005-01-31 to 2007-08-15, status date 2005-02-01, A marks actual dates.
WITS Univeristy

## Calendars

- Standard: Mon-Fri 08:00-12:00, 13:00-17:00; Sat-Sun off.

## Resources

| Resource |
| --- |
| DPW |
| Pro/Mun |
| Prov/Mun |
| CETA |
| Management Team |
| Training Provider |
| Selection Com |
| ABSA |
| Consultant |
| Mentor |
| Learner |
| ETQA CETA |
| DOL |
| IDT |
| Learner Candidates |
| CETA Regional |
| CETA H/O |

## Schedule

| ID | WBS | Task | Duration | Start | Finish | Predecessors | Complete | Remaining | Baseline start | Baseline finish | Baseline duration | Total slack | Free slack | Resources | Work | Actual work |
| --- | --- | --- | --- | --- | --- | --- | --- | --- | --- | --- | --- | --- | --- | --- | --- | --- |
| 1 | 1 | **Application Phase** | 16d | 2005-01-31 A | 2005-02-21 |  | 13% | 14d | 2005-01-31 | 2005-02-21 | 16d | 0d |  |  | 256h | 16h |
| 2 | 1.1 | Application to DPW | 3d | 2005-01-31 A | 2005-02-02 |  | 67% | 1d | 2005-01-31 | 2005-02-02 | 3d | 0d |  | Prov/Mun | 24h | 16h |
| 3 | 1.2 | Discuss implications and requirements as per MOA with Province/Municipality | 10d | 2005-02-03 | 2005-02-16 | 2 |  |  | 2005-02-03 | 2005-02-16 | 10d | 0d |  | DPW; Prov/Mun | 160h |  |
| 4 | 1.3 | Sign MOU (all three parties) | 3d | 2005-02-17 | 2005-02-21 | 3 |  |  | 2005-02-17 | 2005-02-21 | 3d | 0d |  | DPW; Prov/Mun; CETA | 72h |  |
| 5 | 2 | **Establish Management Team** | 10d | 2005-02-22 | 2005-03-07 |  |  |  | 2005-02-22 | 2005-03-07 | 10d | 0d |  | DPW; Prov/Mun; CETA | 384h |  |
| 6 | 2.1 | Appoint team | 2d | 2005-02-22 | 2005-02-23 | 4 |  |  | 2005-02-22 | 2005-02-23 | 2d | 0d |  | CETA; DPW | 32h |  |
| 7 | 2.2 | Chairperson | 1d | 2005-02-22 | 2005-02-22 | 6SS |  |  | 2005-02-22 | 2005-02-22 | 1d | 638d | 1d | DPW; CETA | 16h |  |
| 8 | 2.3 | Champion | 1d | 2005-02-22 | 2005-02-22 | 6SS |  |  | 2005-02-22 | 2005-02-22 | 1d | 638d | 1d | Prov/Mun; CETA | 16h |  |
| 9 | 2.4 | Secretariat | 2d | 2005-02-22 | 2005-02-23 | 6SS |  |  | 2005-02-22 | 2005-02-23 | 2d | 637d | 0d | Management Team | 16h |  |
| 10 | 2.5 | Housekeeping | 8d | 2005-02-24 | 2005-03-07 | 7, 8, 9 |  |  | 2005-02-24 | 2005-03-07 | 8d | 637d |  | Management Team | 64h |  |
| 11 | 3 | **Preparation Phase (Learnerships)** | 54d | 2005-02-24 | 2005-05-10 |  |  |  | 2005-02-24 | 2005-05-10 | 54d | 0d |  |  | 568h |  |
| 12 | 3.1 | Notify CETA to appoint Training Provider (Training; Assessment) | 1d | 2005-02-24 | 2005-02-24 | 6 |  |  | 2005-02-24 | 2005-02-24 | 1d | 0d |  | Management Team | 8h |  |
| 13 | 3.2 | Appoint Training Provider | 15d | 2005-02-25 | 2005-03-17 | 12 |  |  | 2005-02-25 | 2005-03-17 | 15d | 0d |  | CETA | 120h |  |
| 14 | 3.3 | Establish Selection Committee | 2d | 2005-03-16 | 2005-03-17 | 13FS-2d |  |  | 2005-03-16 | 2005-03-17 | 2d | 0d |  | Management Team; ABSA | 32h |  |
| 15 | 3.4 | Training plan | 5d | 2005-03-18 | 2005-03-24 | 13 |  |  | 2005-03-18 | 2005-03-24 | 5d | 42d | 0d | Training Provider | 40h |  |
| 16 | 3.5 | Selection Plan (Technicon Students, Resident Based, etc.) | 5d | 2005-03-18 | 2005-03-24 | 13 |  |  | 2005-03-18 | 2005-03-24 | 5d | 42d | 0d | Management Team | 40h |  |
| 17 | 3.6 | Communicate / Present Training plan to Province/Municipality/Management Team | 3d | 2005-03-25 | 2005-03-29 | 16, 15 |  |  | 2005-03-25 | 2005-03-29 | 3d | 42d | 0d | Prov/Mun; Training Provider; Management Team | 72h |  |
| 18 | 3.7 | Approve Training Plan | 2d | 2005-03-30 | 2005-03-31 | 17 |  |  | 2005-03-30 | 2005-03-31 | 2d | 55d |  | Management Team | 16h |  |
| 19 | 3.8 | Appoint, Brief & Train Mentor | 30d | 2005-03-30 | 2005-05-10 | 17 |  |  | 2005-03-30 | 2005-05-10 | 30d | 42d | 0d | DPW | 240h |  |
| 20 | 4 | **Selection Process** | 102d | 2005-03-18 | 2005-08-08 |  |  |  | 2005-03-18 | 2005-08-08 | 102d | 0d |  |  | 1008h |  |
| 21 | 4.1 | Agree on selection process (based on guidelines from DPW and inputs from Banks) | 5d | 2005-03-18 | 2005-03-24 | 14 |  |  | 2005-03-18 | 2005-03-24 | 5d | 0d |  | Management Team | 40h |  |
| 22 | 4.2 | Prepare addvertisement for approval by CETA and DPW | 2d | 2005-03-25 | 2005-03-28 | 21 |  |  | 2005-03-25 | 2005-03-28 | 2d | 0d |  | Prov/Mun | 16h |  |
| 23 | 4.3 | Advertise | 10d | 2005-03-29 | 2005-04-11 | 22 |  |  | 2005-03-29 | 2005-04-11 | 10d | 0d |  | Prov/Mun | 80h |  |
| 24 | 4.4 | Briefing Session | 1d | 2005-04-12 | 2005-04-12 | 23 |  |  | 2005-04-12 | 2005-04-12 | 1d | 0d |  | Management Team | 8h |  |
| 25 | 4.5 | Invite applications | 1d | 2005-04-13 | 2005-04-13 | 24 |  |  | 2005-04-13 | 2005-04-13 | 1d | 0d |  | Management Team | 8h |  |
| 26 | 4.6 | Opening Applications | 1d | 2005-04-21 | 2005-04-21 | 25FS+5d |  |  | 2005-04-21 | 2005-04-21 | 1d | 0d |  | Selection Com | 8h |  |
| 27 | 4.7 | Assess completed forms ito criteria | 2d | 2005-04-22 | 2005-04-25 | 26 |  |  | 2005-04-22 | 2005-04-25 | 2d | 0d |  | Training Provider | 16h |  |
| 28 | 4.8 | Pre-evalaution | 2d | 2005-04-26 | 2005-04-27 | 27 |  |  | 2005-04-26 | 2005-04-27 | 2d | 0d |  | Management Team | 16h |  |
| 29 | 4.9 | Detailed written Assesment by Learner Candidates | 1d | 2005-05-06 | 2005-05-06 | 28FS+6d |  |  | 2005-05-06 | 2005-05-06 | 1d | 0d |  | Selection Com | 8h |  |
| 30 | 4.10 | Evaluation report with Recommendations by Training provider to Committee | 3d | 2005-05-09 | 2005-05-11 | 29 |  |  | 2005-05-09 | 2005-05-11 | 3d | 0d |  | Training Provider | 24h |  |
| 31 | 4.11 | Shortlist Learner Candidates for interviews | 1d | 2005-05-12 | 2005-05-12 | 30 |  |  | 2005-05-12 | 2005-05-12 | 1d | 0d |  | Management Team | 8h |  |
| 32 | 4.12 | Provision of shortlisted Learner details to ABSA | 1d | 2005-05-27 | 2005-05-27 | 31FS+10d |  |  | 2005-05-27 | 2005-05-27 | 1d | 0d |  | ABSA; Management Team | 16h |  |
| 33 | 4.13 | Interview Learner Candidates | 3d | 2005-05-30 | 2005-06-01 | 32 |  |  | 2005-05-30 | 2005-06-01 | 3d | 0d |  | Selection Com; Learner Candidates | 48h |  |
| 34 | 4.14 | Final Approval of learners | 2d | 2005-06-02 | 2005-06-03 | 33 |  |  | 2005-06-02 | 2005-06-03 | 2d | 0d |  | Selection Com | 16h |  |
| 35 | 4.15 | Notify learners of selection | 1d | 2005-06-06 | 2005-06-06 | 34 |  |  | 2005-06-06 | 2005-06-06 | 1d | 0d |  | Selection Com | 8h |  |
| 36 | 4.16 | Complete CETA database to prepare Learnership Agreements | 4d | 2005-06-07 | 2005-06-10 | 35 |  |  | 2005-06-07 | 2005-06-10 | 4d | 0d |  | Training Provider | 32h |  |
| 37 | 4.17 | Send Learner database to CETA Regional Office (copy H/O) | 1d | 2005-06-13 | 2005-06-13 | 36 |  |  | 2005-06-13 | 2005-06-13 | 1d | 0d |  | Training Provider | 8h |  |
| 38 | 4.18 | Regional CETA office verifies data and send to H/O | 3d | 2005-06-14 | 2005-06-16 | 37 |  |  | 2005-06-14 | 2005-06-16 | 3d | 0d |  | CETA Regional | 24h |  |
| 39 | 4.19 | H/O Prepares learnership agreements (allocate L/S number & print) | 4d | 2005-06-17 | 2005-06-22 | 18, 19SS+10d, 38 |  |  | 2005-06-17 | 2005-06-22 | 4d | 0d |  | Training Provider; CETA | 64h |  |
| 40 | 4.20 | Provide Learnership agreements to Training provider/Province/Municipality | 2d | 2005-06-23 | 2005-06-24 | 39 |  |  | 2005-06-23 | 2005-06-24 | 2d | 558d |  | CETA H/O | 16h |  |
| 41 | 4.21 | Induction- Introduction of Programme to learners | 1d | 2005-06-27 | 2005-06-27 | 39FS+2d |  |  | 2005-06-27 | 2005-06-27 | 1d | 0d |  | Management Team; Training Provider; ABSA | 24h |  |
| 42 | 4.22 | Sign Learnership agreement | 1d | 2005-06-27 | 2005-06-27 | 41FF |  |  | 2005-06-27 | 2005-06-27 | 1d | 0d |  | CETA; Learner | 16h |  |
| 43 | 4.23 | Send copy of cover, signature page and ID document to CETA H/O | 1d | 2005-06-28 | 2005-06-28 | 42 |  |  | 2005-06-28 | 2005-06-28 | 1d | 546d | 0d |  |  |  |
| 44 | 4.24 | CETA H/O register learner on CETA database | 2d | 2005-07-01 | 2005-07-04 | 43FS+2d |  |  | 2005-07-01 | 2005-07-04 | 2d | 546d | 0d |  |  |  |
| 45 | 4.25 | CETA H/O prepares invoice template for Training provider/Province/Municipality | 5d | 2005-07-05 | 2005-07-11 | 44 |  |  | 2005-07-05 | 2005-07-11 | 5d | 546d | 0d |  |  |  |
| 46 | 4.26 | Training Provider/Province/Municipality start claming payments and grants | 1d | 2005-07-12 | 2005-07-12 | 45 |  |  | 2005-07-12 | 2005-07-12 | 1d | 546d |  |  |  |  |
| 47 | 4.27 | Sign Contract of Employment | 1d | 2005-06-27 | 2005-06-27 | 41FF |  |  | 2005-06-27 | 2005-06-27 | 1d | 26d | 0d | Prov/Mun; Learner | 16h |  |
| 48 | 4.28 | Registration of New Close Corporations | 20d | 2005-06-28 | 2005-07-25 | 47 |  |  | 2005-06-28 | 2005-07-25 | 20d | 26d | 0d | Management Team; Mentor | 320h |  |
| 49 | 4.29 | Financial Compliance/VAT, etc of new Learner Contracting Comp. | 10d | 2005-07-26 | 2005-08-08 | 48 |  |  | 2005-07-26 | 2005-08-08 | 10d | 26d | 25d | Mentor; Management Team | 160h |  |
| 50 | 4.30 | Registration with DOL | 1d | 2005-07-01 | 2005-07-01 | 42SF+5d |  |  | 2005-07-01 | 2005-07-01 | 1d | 553d |  | CETA | 8h |  |

| ID | WBS | Task | Duration | Start | Finish | Predecessors | Baseline start | Baseline finish | Baseline duration | Total slack | Free slack | Constraint | Resources | Work |
| --- | --- | --- | --- | --- | --- | --- | --- | --- | --- | --- | --- | --- | --- | --- |
| 51 | 5 | **Preparation Phase (Projects)** | 70d | 2005-04-20 | 2005-07-26 |  | 2005-04-20 | 2005-07-26 | 70d | 42d |  |  |  | 680h |
| 52 | 5.1 | Identify and allocate projects | 5d | 2005-04-20 | 2005-04-26 | 19SS+15d | 2005-04-20 | 2005-04-26 | 5d | 42d | 0d |  | Prov/Mun | 40h |
| 53 | 5.2 | Prepare project plan | 10d | 2005-04-27 | 2005-05-10 | 52 | 2005-04-27 | 2005-05-10 | 10d | 42d | 0d |  | Prov/Mun | 80h |
| 54 | 5.3 | Appoint and Brief Consultants | 15d | 2005-05-11 | 2005-05-31 | 53 | 2005-05-11 | 2005-05-31 | 15d | 42d | 0d |  | Prov/Mun | 120h |
| 55 | 5.4 | Design and Prepare Documentation | 20d | 2005-06-01 | 2005-06-28 | 54 | 2005-06-01 | 2005-06-28 | 20d | 42d | 0d |  | Consultant | 160h |
| 56 | 5.5 | Construction Implementation Plan | 10d | 2005-06-29 | 2005-07-12 | 55 | 2005-06-29 | 2005-07-12 | 10d | 42d | 0d |  | Mentor | 80h |
| 57 | 5.6 | Financial Planning | 5d | 2005-07-13 | 2005-07-19 | 56 | 2005-07-13 | 2005-07-19 | 5d | 42d | 0d |  | Mentor; ABSA; Consultant | 120h |
| 58 | 5.7 | Determine Commencement of Construction | 5d | 2005-07-20 | 2005-07-26 | 57 | 2005-07-20 | 2005-07-26 | 5d | 42d |  |  | Consultant; Mentor | 80h |
| 59 | 6 | **Classroom and Practical Training** | 593d | 2005-03-25 | 2007-07-03 |  | 2005-03-25 | 2007-07-03 | 593d | 31d |  |  |  | 10136h |
| 60 | 6.1 | Prepare for classroom training (logistics, accomodation etc) | 7d | 2005-03-25 | 2005-04-04 | 17SS | 2005-03-25 | 2005-04-04 | 7d | 617d |  |  | Training Provider; Management Team | 112h |
| 61 | 6.2 | Establish Training Sites (Tools, equipment etc) | 15d | 2005-03-25 | 2005-04-14 | 17SS | 2005-03-25 | 2005-04-14 | 15d | 609d |  |  | Training Provider | 120h |
| 62 | 6.3 | Induction on the Bank’s facility | 5d | 2005-06-28 | 2005-07-04 | 18, 42 | 2005-06-28 | 2005-07-04 | 5d | 0d |  |  | ABSA | 40h |
| 63 | 6.4 | **Phase 1 - Classroom Training** | 60d | 2005-06-30 | 2005-09-21 |  | 2005-06-30 | 2005-09-21 | 60d | 0d |  |  | Training Provider | 960h |
| 64 | 6.4.1 | Classroom and hands on training | 60d | 2005-06-30 | 2005-09-21 | 62SS+2d, 42 | 2005-06-30 | 2005-09-21 | 60d | 0d |  |  | Training Provider | 480h |
| 65 | 6.5 | **Phase 2 – On-site Training Project** | 102d | 2005-08-25 | 2006-01-13 |  | 2005-08-25 | 2006-01-13 | 102d | 0d |  |  |  | 2072h |
| 66 | 6.5.1 | Negotiate rates with learner contractors | 10d | 2005-08-25 | 2005-09-07 | 64FS-20d | 2005-08-25 | 2005-09-07 | 10d | 0d |  | start no earlier than 2004-08-01 | Prov/Mun; Mentor; Learner; Consultant; Training Provider | 400h |
| 67 | 6.5.2 | Final approval of rates by DPW | 3d | 2005-09-08 | 2005-09-12 | 66 | 2005-09-08 | 2005-09-12 | 3d | 0d |  |  | DPW | 24h |
| 68 | 6.5.3 | Preparation of Cash Flows | 3d | 2005-09-09 | 2005-09-13 | 67SS+1d | 2005-09-09 | 2005-09-13 | 3d | 0d |  |  | Mentor; Learner | 48h |
| 69 | 6.5.4 | Sign contract between Province/Municipality and the Learner contractor | 2d | 2005-09-13 | 2005-09-14 | 67, 49 | 2005-09-13 | 2005-09-14 | 2d | 1d | 0d |  | Prov/Mun; Learner | 32h |
| 70 | 6.5.5 | Sign contract with bank/ Project Financing | 2d | 2005-09-14 | 2005-09-15 | 69SS, 68 | 2005-09-14 | 2005-09-15 | 2d | 0d |  |  | ABSA; Learner; Mentor | 48h |
| 71 | 6.5.6 | Arrange Overdraft Facilities | 5d | 2005-09-16 | 2005-09-22 | 70 | 2005-09-16 | 2005-09-22 | 5d | 0d |  |  | ABSA; Mentor | 80h |
| 72 | 6.5.7 | Recruitment of Labour and Artisans | 4d | 2005-09-15 | 2005-09-20 | 69 | 2005-09-15 | 2005-09-20 | 4d | 2d | 0d |  | Learner; Mentor; Prov/Mun; DOL; IDT | 160h |
| 73 | 6.5.8 | Commence On site training project | 1d | 2005-09-23 | 2005-09-23 | 72, 58, 71 | 2005-09-23 | 2005-09-23 | 1d | 0d |  |  | Learner | 8h |
| 74 | 6.5.9 | Site Establishment, Planning, Requisition of Tools, Materials, etc. | 5d | 2005-09-26 | 2005-09-30 | 73 | 2005-09-26 | 2005-09-30 | 5d | 0d |  |  | Learner; Mentor | 80h |
| 75 | 6.5.10 | Notify DOL for EPWP worker Training | 3d | 2005-09-15 | 2005-09-19 | 72SS | 2005-09-15 | 2005-09-19 | 3d | 497d |  |  | Mentor; Learner; IDT | 72h |
| 76 | 6.5.11 | Execution of training project | 65d | 2005-10-03 | 2005-12-30 | 74 | 2005-10-03 | 2005-12-30 | 65d | 0d |  |  | Learner; Mentor | 1040h |
| 77 | 6.5.12 | EPWP Worker Life Skills Training | 10d | 2006-01-02 | 2006-01-13 | 76 | 2006-01-02 | 2006-01-13 | 10d | 413d |  |  | DOL | 80h |

| ID | WBS | Task | Duration | Start | Finish | Predecessors | Baseline start | Baseline finish | Baseline duration | Total slack | Resources | Work |
| --- | --- | --- | --- | --- | --- | --- | --- | --- | --- | --- | --- | --- |
| 78 | 6.6 | **Phase 3 - Classroom Training** | 60d | 2006-01-02 | 2006-03-24 |  | 2006-01-02 | 2006-03-24 | 60d | 0d |  | 480h |
| 79 | 6.6.1 | Classroom training | 60d | 2006-01-02 | 2006-03-24 | 76 | 2006-01-02 | 2006-03-24 | 60d | 0d | Training Provider | 480h |
| 80 | 6.7 | **Phase 4 – On-site Training Project** | 145d | 2006-02-27 | 2006-09-15 |  | 2006-02-27 | 2006-09-15 | 145d | 0d |  | 2704h |
| 81 | 6.7.1 | Negotiate rates with learner contractors | 10d | 2006-02-27 | 2006-03-10 | 79FS-20d | 2006-02-27 | 2006-03-10 | 10d | 0d | Prov/Mun; Mentor; Learner; Consultant; Training Provider | 400h |
| 82 | 6.7.2 | Final approval of rates by DPW | 3d | 2006-03-13 | 2006-03-15 | 81 | 2006-03-13 | 2006-03-15 | 3d | 0d | DPW | 24h |
| 83 | 6.7.3 | Preparation of Cash Flows | 3d | 2006-03-14 | 2006-03-16 | 82SS+1d | 2006-03-14 | 2006-03-16 | 3d | 0d | Mentor; Learner | 48h |
| 84 | 6.7.4 | Sign contract between Province/Municipality and the Learner contractor | 2d | 2006-03-17 | 2006-03-20 | 83 | 2006-03-17 | 2006-03-20 | 2d | 0d | Prov/Mun; Learner | 32h |
| 85 | 6.7.5 | Sign contract with bank/ Project Financing | 2d | 2006-03-17 | 2006-03-20 | 84SS | 2006-03-17 | 2006-03-20 | 2d | 0d | ABSA; Learner; Mentor | 48h |
| 86 | 6.7.6 | Arrange Overdraft Facilities | 5d | 2006-03-21 | 2006-03-27 | 85 | 2006-03-21 | 2006-03-27 | 5d | 0d | ABSA; Mentor | 80h |
| 87 | 6.7.7 | Recruitment of Labour and Artisans | 4d | 2006-03-28 | 2006-03-31 | 86 | 2006-03-28 | 2006-03-31 | 4d | 0d | Learner; Mentor; Prov/Mun; DOL; IDT | 160h |
| 88 | 6.7.8 | Commence On site training project | 5d | 2006-04-03 | 2006-04-07 | 87 | 2006-04-03 | 2006-04-07 | 5d | 0d | Learner; Mentor | 80h |
| 89 | 6.7.9 | Site Establishment, Planning, Requisition of Tools, Materials, etc. | 5d | 2006-04-10 | 2006-04-14 | 88 | 2006-04-10 | 2006-04-14 | 5d | 0d | Learner; Mentor | 80h |
| 90 | 6.7.10 | Notify DOL for EPWP worker Training | 3d | 2006-03-28 | 2006-03-30 | 87SS | 2006-03-28 | 2006-03-30 | 3d | 359d | Mentor; Learner; IDT | 72h |
| 91 | 6.7.11 | Execution of training project | 100d | 2006-04-17 | 2006-09-01 | 89 | 2006-04-17 | 2006-09-01 | 100d | 0d | Learner; Mentor | 1600h |
| 92 | 6.7.12 | EPWP Worker Life Skills Training | 10d | 2006-09-04 | 2006-09-15 | 91 | 2006-09-04 | 2006-09-15 | 10d | 238d | DOL | 80h |
| 93 | 6.8 | **Phase 5 - Classroom Training** | 60d | 2006-09-04 | 2006-11-24 |  | 2006-09-04 | 2006-11-24 | 60d | 0d |  | 480h |
| 94 | 6.8.1 | Classroom training | 60d | 2006-09-04 | 2006-11-24 | 91 | 2006-09-04 | 2006-11-24 | 60d | 0d | Training Provider | 480h |
| 95 | 6.9 | **Phase 6 – On-site Training Project** | 177d | 2006-10-30 | 2007-07-03 |  | 2006-10-30 | 2007-07-03 | 177d | 0d |  | 3168h |
| 96 | 6.9.1 | Negotiate rates with learner contractors | 10d | 2006-10-30 | 2006-11-10 | 94FS-20d | 2006-10-30 | 2006-11-10 | 10d | 0d | Prov/Mun; Mentor; Learner; Consultant; Training Provider | 400h |
| 97 | 6.9.2 | Final approval of rates by DPW | 3d | 2006-11-13 | 2006-11-15 | 96 | 2006-11-13 | 2006-11-15 | 3d | 0d | DPW | 24h |
| 98 | 6.9.3 | Preparation of Cash Flows | 3d | 2006-11-14 | 2006-11-16 | 97SS+1d | 2006-11-14 | 2006-11-16 | 3d | 0d | Mentor; Learner | 48h |
| 99 | 6.9.4 | Sign contract between Province/Municipality and the Learner contractor | 2d | 2006-11-17 | 2006-11-20 | 98 | 2006-11-17 | 2006-11-20 | 2d | 0d | Prov/Mun; Learner | 32h |
| 100 | 6.9.5 | Sign contract with bank/ Project Financing | 2d | 2006-11-17 | 2006-11-20 | 99SS | 2006-11-17 | 2006-11-20 | 2d | 0d | ABSA; Learner; Mentor | 48h |
| 101 | 6.9.6 | Arrange Overdraft Facilities | 5d | 2006-11-21 | 2006-11-27 | 100 | 2006-11-21 | 2006-11-27 | 5d | 0d | ABSA; Mentor | 80h |
| 102 | 6.9.7 | Recruitment of Labour and Artisans | 5d | 2006-11-28 | 2006-12-04 | 101 | 2006-11-28 | 2006-12-04 | 5d | 0d | Learner; Mentor; Prov/Mun; DOL | 160h |
| 103 | 6.9.8 | Commence On site training project | 1d | 2006-12-05 | 2006-12-05 | 102 | 2006-12-05 | 2006-12-05 | 1d | 0d | Learner | 8h |
| 104 | 6.9.9 | Site Establishment, Planning, Requisition of Tools, Materials, etc. | 5d | 2006-12-06 | 2006-12-12 | 103 | 2006-12-06 | 2006-12-12 | 5d | 0d | Mentor; Learner | 80h |
| 105 | 6.9.10 | Notify DOL for EPWP worker Training | 3d | 2006-11-28 | 2006-11-30 | 102SS | 2006-11-28 | 2006-11-30 | 3d | 184d | Mentor; Learner | 48h |
| 106 | 6.9.11 | Execution of training project | 135d | 2006-12-13 | 2007-06-19 | 104 | 2006-12-13 | 2007-06-19 | 135d | 0d | Learner; Mentor | 2160h |
| 107 | 6.9.12 | EPWP Worker Life Skills Training | 10d | 2007-06-20 | 2007-07-03 | 106 | 2007-06-20 | 2007-07-03 | 10d | 31d | DOL | 80h |

| ID | WBS | Task | Duration | Start | Finish | Predecessors | Baseline start | Baseline finish | Baseline duration | Total slack | Free slack | Resources | Work |
| --- | --- | --- | --- | --- | --- | --- | --- | --- | --- | --- | --- | --- | --- |
| 108 | 7 | **Reporting (Training)** | 352d | 2005-09-22 | 2007-01-26 |  | 2005-09-22 | 2007-01-26 | 352d | 143d |  |  | 1440h |
| 109 | 7.1 | **Phased assessment reports after completion of training modules** | 317d | 2005-09-22 | 2006-12-08 |  | 2005-09-22 | 2006-12-08 | 317d | 143d |  |  | 240h |
| 110 | 7.1.1 | Phase 1 | 10d | 2005-09-22 | 2005-10-05 | 64 | 2005-09-22 | 2005-10-05 | 10d | 450d | 0d | Training Provider | 80h |
| 111 | 7.1.2 | Phase 3 | 10d | 2006-03-27 | 2006-04-07 | 79 | 2006-03-27 | 2006-04-07 | 10d | 318d | 0d | Training Provider | 80h |
| 112 | 7.1.3 | Phase 5 | 10d | 2006-11-27 | 2006-12-08 | 94 | 2006-11-27 | 2006-12-08 | 10d | 143d | 0d | Training Provider | 80h |
| 113 | 7.2 | **Assessment, Moderation and Verification Reports** | 322d | 2005-10-06 | 2006-12-29 |  | 2005-10-06 | 2006-12-29 | 322d | 143d |  |  | 720h |
| 114 | 7.2.1 | Phase 1 | 15d | 2005-10-06 | 2005-10-26 | 110 | 2005-10-06 | 2005-10-26 | 15d | 450d | 0d | Training Provider; ETQA CETA | 240h |
| 115 | 7.2.2 | Phase 3 | 15d | 2006-04-10 | 2006-04-28 | 111 | 2006-04-10 | 2006-04-28 | 15d | 318d | 0d | Training Provider; ETQA CETA | 240h |
| 116 | 7.2.3 | Phase 5 | 15d | 2006-12-11 | 2006-12-29 | 112 | 2006-12-11 | 2006-12-29 | 15d | 143d | 0d | Training Provider; ETQA CETA | 240h |
| 117 | 7.3 | **Phased Progress report to DPW EPWP Unit** | 317d | 2005-10-27 | 2007-01-12 |  | 2005-10-27 | 2007-01-12 | 317d | 143d |  |  | 240h |
| 118 | 7.3.1 | Phase 1 | 10d | 2005-10-27 | 2005-11-09 | 114 | 2005-10-27 | 2005-11-09 | 10d | 450d | 0d | Management Team | 80h |
| 119 | 7.3.2 | Phase 3 | 10d | 2006-05-01 | 2006-05-12 | 115 | 2006-05-01 | 2006-05-12 | 10d | 318d | 0d | Management Team | 80h |
| 120 | 7.3.3 | Phase 5 | 10d | 2007-01-01 | 2007-01-12 | 116 | 2007-01-01 | 2007-01-12 | 10d | 143d | 0d | Management Team | 80h |
| 121 | 7.4 | **Registration of Achievements with DOL** | 317d | 2005-11-10 | 2007-01-26 |  | 2005-11-10 | 2007-01-26 | 317d | 143d |  |  | 240h |
| 122 | 7.4.1 | Phase 1 | 10d | 2005-11-10 | 2005-11-23 | 118 | 2005-11-10 | 2005-11-23 | 10d | 450d |  | CETA | 80h |
| 123 | 7.4.2 | Phase 3 | 10d | 2006-05-15 | 2006-05-26 | 119 | 2006-05-15 | 2006-05-26 | 10d | 318d |  | CETA | 80h |
| 124 | 7.4.3 | Phase 5 | 10d | 2007-01-15 | 2007-01-26 | 120 | 2007-01-15 | 2007-01-26 | 10d | 143d |  | CETA | 80h |
| 125 | 8 | **Reporitng (Mentoring)** | 422d | 2006-01-02 | 2007-08-14 |  | 2006-01-02 | 2007-08-14 | 422d | 1d |  |  | 960h |
| 126 | 8.1 | **Phased Progress Mentoring reports to Management Team** | 397d | 2006-01-02 | 2007-07-10 |  | 2006-01-02 | 2007-07-10 | 397d | 1d |  |  | 360h |
| 127 | 8.1.1 | Phase 2 | 15d | 2006-01-02 | 2006-01-20 | 76 | 2006-01-02 | 2006-01-20 | 15d | 383d | 0d | Mentor | 120h |
| 128 | 8.1.2 | Phase 4 | 15d | 2006-09-04 | 2006-09-22 | 91 | 2006-09-04 | 2006-09-22 | 15d | 208d | 0d | Mentor | 120h |
| 129 | 8.1.3 | Phase 6 | 15d | 2007-06-20 | 2007-07-10 | 106 | 2007-06-20 | 2007-07-10 | 15d | 0d |  | Mentor | 120h |
| 130 | 8.2 | **Assesment report of learners** | 397d | 2006-01-23 | 2007-07-31 |  | 2006-01-23 | 2007-07-31 | 397d | 1d |  |  | 360h |
| 131 | 8.2.1 | Phase 2 | 15d | 2006-01-23 | 2006-02-10 | 127 | 2006-01-23 | 2006-02-10 | 15d | 383d | 0d | Mentor | 120h |
| 132 | 8.2.2 | Phase 4 | 15d | 2006-09-25 | 2006-10-13 | 128 | 2006-09-25 | 2006-10-13 | 15d | 208d | 0d | Mentor | 120h |
| 133 | 8.2.3 | Phase 6 | 15d | 2007-07-11 | 2007-07-31 | 129 | 2007-07-11 | 2007-07-31 | 15d | 0d |  | Mentor | 120h |

| ID | WBS | Task | Duration | Start | Finish | Predecessors | Baseline start | Baseline finish | Baseline duration | Total slack | Resources | Work |
| --- | --- | --- | --- | --- | --- | --- | --- | --- | --- | --- | --- | --- |
| 134 | 8.3 | **Phased Progress report to DPW EPWP Unit** | 392d | 2006-02-13 | 2007-08-14 |  | 2006-02-13 | 2007-08-14 | 392d | 1d |  | 240h |
| 135 | 8.3.1 | Phase 2 | 10d | 2006-02-13 | 2006-02-24 | 131 | 2006-02-13 | 2006-02-24 | 10d | 383d | Mentor | 80h |
| 136 | 8.3.2 | Phase 4 | 10d | 2006-10-16 | 2006-10-27 | 132 | 2006-10-16 | 2006-10-27 | 10d | 208d | Mentor | 80h |
| 137 | 8.3.3 | Phase 6 | 10d | 2007-08-01 | 2007-08-14 | 133 | 2007-08-01 | 2007-08-14 | 10d | 0d | Mentor | 80h |
| 138 | 9 | **Three way evalaution - on completion of programme** | 1d | 2007-08-15 | 2007-08-15 |  | 2007-08-15 | 2007-08-15 | 1d | 0d |  | 24h |
| 139 | 9.1 | Learner evaluates Training Provider and Mentor | 1d | 2007-08-15 | 2007-08-15 | 137 | 2007-08-15 | 2007-08-15 | 1d | 0d | Learner | 8h |
| 140 | 9.2 | Mentor evalautes Training Provider and learner | 1d | 2007-08-15 | 2007-08-15 | 139SS | 2007-08-15 | 2007-08-15 | 1d | 0d | Mentor | 8h |
| 141 | 9.3 | Training Provider evaluates learner and mentor | 1d | 2007-08-15 | 2007-08-15 | 140SS | 2007-08-15 | 2007-08-15 | 1d | 0d | Training Provider | 8h |
